# Semesterarbeit SS07

Schedule from Planner, 2007-03-19 to 2007-09-14.

## Calendars

- Vorgabe: Mon-Fri 08:00-12:00, 13:00-17:00; Sat-Sun off.

## Schedule

| ID | WBS | Task | Type | Duration | Start | Finish | Predecessors | Constraint | Work |
| --- | --- | --- | --- | --- | --- | --- | --- | --- | --- |
| 1 | 1 | **Einarbeitung** |  |  | 2007-03-19 | 2007-03-23 |  |  | 56h |
| 2 | 1.1 | Lesen |  |  | 2007-03-19 | 2007-03-20 |  |  | 16h |
| 3 | 1.2 | Tools auswählen, Setup erstellen |  |  | 2007-03-19 | 2007-03-23 |  |  | 40h |
| 4 | 2 | **Entwicklung** |  |  | 2007-03-26 | 2007-06-28 | 1 |  | 552h |
| 5 | 2.1 | Programmieren an Topsy.386-pci |  |  | 2007-03-26 | 2007-03-28 |  |  | 24h |
| 6 | 2.2 | Programmieren Topsy v3 auf P4 |  |  | 2007-03-29 | 2007-06-28 | 7 |  | 528h |
| 7 | 2.3 | Topsy.386-pci bootet | milestone | 0d | 2007-03-28 | 2007-03-28 | 5 |  |  |
| 8 | 2.4 | Topsy v3 auf P4 | milestone | 0d | 2007-06-28 | 2007-06-28 | 6 |  |  |
| 9 | 3 | Test / Debugging |  |  | 2007-03-26 | 2007-07-20 | 1, 4SS |  | 680h |
| 10 | 4 | Evaluation |  |  | 2007-06-18 | 2007-08-03 | 1 | must start on 2007-06-18 | 280h |
| 11 | 5 | **Dokumentation** |  |  | 2007-03-19 | 2007-09-14 |  |  | 1120h |
| 12 | 5.1 | Logs, Doku |  |  | 2007-03-19 | 2007-07-12 |  |  | 672h |
| 13 | 5.2 | Vorbereitung Zwischenpräsentation |  |  | 2007-05-15 | 2007-05-21 |  | must start on 2007-05-15 | 40h |
| 14 | 5.3 | Zwischenpräsentation | milestone | 0d | 2007-05-22 | 2007-05-22 | 13 | must start on 2007-05-22 |  |
| 15 | 5.4 | Vorbereitung Präsentation |  |  | 2007-09-12 | 2007-09-14 |  | must start on 2007-09-12 | 24h |
| 16 | 5.5 | Präsentation | milestone | 0d | 2007-09-14 | 2007-09-14 | 15 |  |  |
| 17 | 5.6 | Bericht |  |  | 2007-06-14 | 2007-08-20 |  | must start on 2007-06-14 | 384h |
| 18 | 5.7 | Abgabe | milestone | 0d | 2007-09-14 | 2007-09-14 | 17, 9, 4, 10 | must start on 2007-09-14 |  |
| 19 | 6 | **Termine** |  |  | 2007-03-19 | 2007-08-20 |  |  | 568h |
| 20 | 6.1 | Semester |  |  | 2007-03-19 | 2007-06-22 |  | must start on 2007-03-19 | 560h |
| 21 | 6.2 | Prüfungssession Start |  |  | 2007-08-20 | 2007-08-20 |  | must start on 2007-08-20 | 8h |
